# Information System Implementation - Project Name

Schedule from MS Project, 2019-11-22 to 2020-03-18.
This template outlines the steps, from an HR perspective and at a very high level, needed to implement an HRIS. It is not specific to any commercial software system.

## Calendars

- Standard: Mon-Fri 08:00-12:00, 13:00-17:00; Sat-Sun off. Exceptions (off unless hours are given): 2019-11-28 to 2019-11-29 (Thanksgiving Break 2019), 2019-12-24 to 2020-01-02 (Christmas Break 2019), 2020-01-20 (MLK Birthday 2020).

## Resources

| Resource |
| --- |
| Executive Management |
| Information Systems |
| Business User (SME) |
| Procurement |
| Project Manager |

## Schedule

| ID | WBS | Task | Type | Duration | Start | Finish | Predecessors | Total slack | Free slack | Constraint | Resources | Work |
| --- | --- | --- | --- | --- | --- | --- | --- | --- | --- | --- | --- | --- |
| 1 | 1 | **Initiation Phase** |  | 3d? | 2019-11-22 | 2019-11-26 |  | 0d |  |  |  | 32h |
| 2 | 1.1 | Create Business Case, Opportunities, Benefits of Request |  | 1d? | 2019-11-22 | 2019-11-22 |  | 0d |  | start no earlier than 2019-11-22 | Business User (SME) | 8h |
| 3 | 1.2 | Create Return on Investment (ROI) |  | 1d? | 2019-11-22 | 2019-11-22 |  | 0d |  | start no earlier than 2019-11-22 | Business User (SME) | 8h |
| 4 | 1.3 | Create Project Charter |  | 1d? | 2019-11-25 | 2019-11-25 | 2, 3 | 0d |  |  | Project Manager | 8h |
| 5 | 1.4 | Present Demand to Project Review Board |  | 1d? | 2019-11-26 | 2019-11-26 | 2, 3, 4 | 0d |  |  | Business User (SME) | 8h |
| 6 | 1.5 | PRB Approved by Executive Management | milestone | 0d | 2019-11-26 | 2019-11-26 | 5 | 0d |  |  |  |  |
| 7 | 2 | **Commodity & Services Acquistion Phase** |  | 11d? | 2019-11-27 | 2019-12-13 |  | 0d |  |  |  | 144h |
| 8 | 2.1 | **Analysis and Requirements** |  | 3d? | 2019-11-27 | 2019-12-03 |  | 0d |  |  |  | 40h |
| 9 | 2.1.1 | **Data Requirements** |  | 3d? | 2019-11-27 | 2019-12-03 |  | 0d |  |  |  | 24h |
| 10 | 2.1.1.1 | Review Existing Materials |  | 1d? | 2019-11-27 | 2019-11-27 | 6 | 0d |  |  | Business User (SME) | 8h |
| 11 | 2.1.1.2 | Conduct User Base Requirements Sessions |  | 1d? | 2019-12-02 | 2019-12-02 | 10 | 0d |  |  | Business User (SME) | 8h |
| 12 | 2.1.1.3 | Develop User Needs Assessment and Complete Business Process Flow |  | 1d? | 2019-12-03 | 2019-12-03 | 11 | 0d |  |  | Business User (SME) | 8h |
| 13 | 2.1.1.4 | Data Requirements Assessment Complete | milestone | 0d | 2019-12-03 | 2019-12-03 | 12 | 64.5d |  |  |  |  |
| 14 | 2.1.2 | **Technical Infrastructure Requirements** |  | 2d? | 2019-11-27 | 2019-12-02 |  | 1d |  |  |  | 16h |
| 15 | 2.1.2.1 | Review Current Infrastructure |  | 1d? | 2019-11-27 | 2019-11-27 | 6 | 1d | 0d |  | Information Systems | 8h |
| 16 | 2.1.2.2 | Project Future Demand |  | 1d? | 2019-12-02 | 2019-12-02 | 15 | 1d | 0d |  | Information Systems | 8h |
| 17 | 2.1.2.3 | Technical Infrastructure Requirements Assessment Complete | milestone | 0d | 2019-12-02 | 2019-12-02 | 16 | 65.5d |  |  |  |  |
| 18 | 2.1.3 | Analysis and Requirements Complete | milestone | 0d | 2019-12-03 | 2019-12-03 | 12, 16 | 0d |  |  |  |  |
| 19 | 2.2 | **Assessment of Solutions** |  | 7d? | 2019-12-04 | 2019-12-12 |  | 0d |  |  |  | 104h |
| 20 | 2.2.1 | Develop RFP |  | 1d? | 2019-12-04 | 2019-12-04 | 18 | 0d |  |  | Business User (SME); Information Systems | 16h |
| 21 | 2.2.2 | Determine Weightings to be Given to Responses |  | 1d? | 2019-12-05 | 2019-12-05 | 20 | 0d |  |  | Business User (SME); Information Systems | 16h |
| 22 | 2.2.3 | Issue RFP |  | 1d? | 2019-12-06 | 2019-12-06 | 21 | 0d |  |  | Procurement | 8h |
| 23 | 2.2.4 | Evaluate Responses |  | 1d? | 2019-12-09 | 2019-12-09 | 22 | 0d |  |  | Business User (SME); Information Systems | 16h |
| 24 | 2.2.5 | Perform Vendor Response/Requirements Gap Analysis |  | 1d? | 2019-12-10 | 2019-12-10 | 23 | 0d |  |  | Business User (SME); Information Systems | 16h |
| 25 | 2.2.6 | Invite Top Candidates to Demo |  | 1d? | 2019-12-11 | 2019-12-11 | 24 | 0d |  |  | Business User (SME); Procurement | 16h |
| 26 | 2.2.7 | Select Best Fit Vendor Solution |  | 1d? | 2019-12-12 | 2019-12-12 | 25 | 0d |  |  | Business User (SME); Information Systems | 16h |
| 27 | 2.2.8 | Assessment of Solutions Complete | milestone | 0d | 2019-12-12 | 2019-12-12 | 26 | 0d |  |  |  |  |
| 28 | 2.3 | Procure Solution |  | 1d? | 2019-12-13 | 2019-12-13 | 27 | 0d |  |  |  |  |

| ID | WBS | Task | Type | Duration | Start | Finish | Predecessors | Total slack | Free slack | Resources | Work |
| --- | --- | --- | --- | --- | --- | --- | --- | --- | --- | --- | --- |
| 29 | 3 | **Planning Phase** |  | 7d? | 2019-12-16 | 2020-01-03 |  | 0d |  |  | 128h |
| 30 | 3.1 | **Iteration Planning** |  | 3d | 2019-12-16 | 2019-12-18 |  | 0d |  |  | 32h |
| 31 | 3.1.1 | Conduct User and Team Training |  | 1d | 2019-12-16 | 2019-12-16 | 28 | 0d |  | Information Systems | 8h |
| 32 | 3.1.2 | Define Iterations |  | 1d | 2019-12-17 | 2019-12-17 | 31 | 2d | 0d | Information Systems | 8h |
| 33 | 3.1.3 | Define Test Approach |  | 1d | 2019-12-17 | 2019-12-17 | 31 | 2d | 0d | Information Systems | 8h |
| 34 | 3.1.4 | Review and Baseline Iteration Plan |  | 1d | 2019-12-18 | 2019-12-18 | 33, 32 | 2d | 0d | Project Manager | 8h |
| 35 | 3.1.5 | Iteration Planning Complete | milestone | 0d | 2019-12-18 | 2019-12-18 | 34 | 2d | 0d |  |  |
| 36 | 3.2 | **Implementation Prototyping** |  | 4d | 2019-12-17 | 2019-12-20 |  | 0d |  |  | 48h |
| 37 | 3.2.1 | Develop Scenarios |  | 1d | 2019-12-17 | 2019-12-17 | 31 | 0d |  | Information Systems | 8h |
| 38 | 3.2.2 | Map Scenarios to Package Transactions |  | 1d | 2019-12-18 | 2019-12-18 | 37 | 53.5d | 2d | Information Systems | 8h |
| 39 | 3.2.3 | Define the Scenario Steps |  | 1d | 2019-12-18 | 2019-12-18 | 37 | 53.5d | 0d | Information Systems | 8h |
| 40 | 3.2.4 | Specify and Prototype Reports |  | 1d | 2019-12-19 | 2019-12-19 | 39 | 53.5d |  | Information Systems | 8h |
| 41 | 3.2.5 | Specify External Interfaces |  | 1d | 2019-12-18 | 2019-12-18 | 37 | 0d |  | Information Systems | 8h |
| 42 | 3.2.6 | Build Package Prototype |  | 1d | 2019-12-19 | 2019-12-19 | 41 | 0d |  | Information Systems | 8h |
| 43 | 3.2.7 | Exercise/Review Package Prototype |  | 1d | 2019-12-20 | 2019-12-20 | 42 | 0d |  |  |  |
| 44 | 3.2.8 | Implementation Prototyping Complete | milestone | 0d | 2019-12-20 | 2019-12-20 | 43 | 0d |  |  |  |
| 45 | 3.3 | **Artifacts** |  | 7d? | 2019-12-16 | 2020-01-03 |  | 51.5d |  |  | 48h |
| 46 | 3.3.1 | Create Communication Plan |  | 4h | 2019-12-16 | 2019-12-16 | 6, 28 | 57.75d | 0d | Project Manager | 8h |
| 47 | 3.3.2 | Publish Communication Plan | milestone | 2h | 2019-12-16 | 2019-12-16 | 46, 28, 1, 7 | 57.75d |  | Project Manager | 8h |
| 48 | 3.3.3 | Finalize Requirements |  | 1d? | 2019-12-16 | 2019-12-16 | 28 | 57.5d |  | Project Manager | 8h |
| 49 | 3.3.4 | Obtain Requirements sign off | milestone | 8h | 2019-12-23 | 2019-12-23 | 44, 36, 30 | 52.5d |  | Project Manager | 8h |
| 50 | 3.3.5 | Produce Project Plan |  | 16h | 2019-12-23 | 2020-01-03 | 1, 7, 37, 38, 44 | 51.5d |  | Project Manager | 8h |
| 51 | 3.3.6 | Create Project Timeline |  | 2h | 2019-12-19 | 2019-12-19 | 28, 32, 35 | 55.25d |  | Project Manager [400%] | 8h |
| 52 | 4 | **Project Execution Phase** |  | 49.5d? | 2019-12-23 | 2020-03-12 | 44 | 0d |  |  | 600h |
| 53 | 4.1 | **Iteration Consolidation** |  | 2d? | 2019-12-23 | 2020-01-03 |  | 51.5d |  |  | 16h |
| 54 | GRBAPI.PC.04.010 | Design Systems and Integration Test Cases |  | 1d? | 2019-12-23 | 2019-12-23 |  | 51.5d | 0d | Information Systems [50%]; Business User (SME) [50%] | 8h |
| 55 | GRBAPI.PC.04.020 | Confirm Scope of Future Iterations |  | 1d? | 2020-01-03 | 2020-01-03 | 54 | 51.5d | 0d | Information Systems [50%]; Business User (SME) [50%] | 8h |
| 56 | 4.1.3 | Iteration Consolidation Complete | milestone | 0d | 2020-01-03 | 2020-01-03 | 55 | 51.5d |  |  |  |

| ID | WBS | Task | Type | Duration | Start | Finish | Predecessors | Total slack | Resources | Work |
| --- | --- | --- | --- | --- | --- | --- | --- | --- | --- | --- |
| 57 | 4.2 | **Data Migration Design** |  | 6d | 2019-12-23 | 2020-01-09 |  | 0d |  | 64h |
| 58 | GRBAPI.PC.05.010 | Review Data Acquisition Strategy |  | 1d | 2019-12-23 | 2019-12-23 | 35 | 0d | Information Systems | 8h |
| 59 | GRBAPI.PC.05.020 | Define Data Migration Sources |  | 1d | 2020-01-03 | 2020-01-03 | 58 | 0d | Information Systems | 8h |
| 60 | GRBAPI.PC.05.030 | Define Data Migration Rules and Logic |  | 1d | 2020-01-06 | 2020-01-06 | 59 | 0d | Information Systems | 8h |
| 61 | GRBAPI.PC.05.040 | Perform Data Cleanup |  | 1d | 2020-01-06 | 2020-01-06 | 59 | 50.5d | Information Systems | 8h |
| 62 | GRBAPI.PC.05.050 | Design Data Migration Transactions |  | 1d | 2020-01-07 | 2020-01-07 | 60, 59 | 49.5d | Information Systems | 8h |
| 63 | GRBAPI.PC.05.060 | Determine Data Migration Procedures and Controls |  | 1d | 2020-01-07 | 2020-01-07 | 60 | 0d | Information Systems | 8h |
| 64 | GRBAPI.PC.05.070 | Review and Baseline Conversion Design |  | 1d | 2020-01-08 | 2020-01-08 | 63 | 0d | Information Systems | 8h |
| 65 | GRBAPI.PC.05.080 | Obtain Signoff of Integration Document |  | 1d | 2020-01-09 | 2020-01-09 | 64 | 0d | Information Systems [50%]; Business User (SME) [50%] | 8h |
| 66 | 4.2.9 | Data Migration Design Complete | milestone | 0d | 2020-01-09 | 2020-01-09 | 65 | 0d |  |  |
| 67 | 4.3 | **Finalize Integration Design Phase** |  | 4d | 2020-01-10 | 2020-01-15 |  | 0d |  | 48h |
| 68 | GRBAPI.PC.GRSEA.010 | Develop Requirements Traceability Matrix |  | 1d | 2020-01-10 | 2020-01-10 | 66 | 0d | Information Systems | 8h |
| 69 | GRBAPI.PC.GRSEA.020 | Baseline Project/Deliverables |  | 1d | 2020-01-13 | 2020-01-13 | 68 | 0d | Information Systems | 8h |
| 70 | GRBAPI.PC.GRSEA.030 | Develop Schedule for Next Stage |  | 1d | 2020-01-14 | 2020-01-14 | 69 | 0d | Information Systems [50%]; Business User (SME) [50%] | 8h |
| 71 | GRBAPI.PC.GRSEA.040 | Review Project Status with Project Board |  | 1d | 2020-01-15 | 2020-01-15 | 70 | 0d | Business User (SME); Executive Management; Information Systems | 24h |
| 72 | 4.3.5 | Finalize Integration Design Phase Complete | milestone | 0d | 2020-01-15 | 2020-01-15 | 71 | 0d |  |  |
| 73 | 4.4 | Integration Design Complete | milestone | 0d | 2020-01-15 | 2020-01-15 | 72 | 0d |  |  |
| 74 | 4.5 | **Integration, Build, Test** |  | 24.5d | 2020-01-16 | 2020-02-20 |  | 0d |  | 320h |
| 75 | 4.5.1 | **Build Iteration Planning** |  | 3d | 2020-01-16 | 2020-01-21 |  | 0d |  | 32h |
| 76 | GRBAPI.PINT.02.010 | Confirm Technical Architecture |  | 1d | 2020-01-16 | 2020-01-16 | 73 | 0d | Information Systems | 8h |
| 77 | GRBAPI.PINT.02.020 | Define Iterations and Builds |  | 1d | 2020-01-17 | 2020-01-17 | 76 | 0d | Information Systems | 8h |
| 78 | GRBAPI.PINT.02.030 | Refine Test Cases |  | 1d | 2020-01-21 | 2020-01-21 | 77 | 0d | Business User (SME); Information Systems | 16h |
| 79 | 4.5.1.4 | Build Iteration Planning Complete | milestone | 0d | 2020-01-21 | 2020-01-21 | 78 | 0d |  |  |
| 80 | 4.5.2 | **Integration Build** |  | 4.5d | 2020-01-22 | 2020-01-28 |  | 0d |  | 56h |
| 81 | GRBAPI.PINT.03.010 | Build Reports |  | 1d | 2020-01-22 | 2020-01-22 | 79 | 0d | Information Systems | 8h |
| 82 | GRBAPI.PINT.03.020 | Design and Build Migration Components |  | 1d | 2020-01-23 | 2020-01-23 | 81 | 0d | Information Systems | 8h |
| 83 | GRBAPI.PINT.03.030 | Design and Build External Interfaces |  | 1d | 2020-01-24 | 2020-01-24 | 82 | 37.5d | Information Systems | 8h |
| 84 | GRBAPI.PINT.03.040 | Optimize Performance |  | 1d | 2020-01-24 | 2020-01-24 | 82 | 37.5d | Information Systems | 8h |
| 85 | GRBAPI.PINT.03.050 | Complete Unit/Integration Testing |  | 1d | 2020-01-23 | 2020-01-24 | 82SS+5% | 0d | Information Systems | 8h |
| 86 | GRBAPI.PINT.03.060 | Review and Baseline Build |  | 1d | 2020-01-24 | 2020-01-27 | 85 | 0d | Information Systems | 8h |
| 87 | GRBAPI.PINT.03.070 | Deliver Build for Testing |  | 1d | 2020-01-27 | 2020-01-28 | 86 | 0d | Information Systems | 8h |
| 88 | 4.5.2.8 | Integration Build Complete | milestone | 0d | 2020-01-28 | 2020-01-28 | 87 | 0d |  |  |

| ID | WBS | Task | Type | Duration | Start | Finish | Predecessors | Total slack | Resources | Work |
| --- | --- | --- | --- | --- | --- | --- | --- | --- | --- | --- |
| 89 | 4.5.3 | **System Test Design and Development** |  | 2d | 2020-01-28 | 2020-01-30 |  | 0d |  | 32h |
| 90 | GRBAPI.PINT.04.010 | Define Test Scripts |  | 1d | 2020-01-28 | 2020-01-29 | 88 | 0d | Information Systems | 8h |
| 91 | GRBAPI.PINT.04.020 | Review Test Case/Requirement Coverage |  | 1d | 2020-01-29 | 2020-01-30 | 90 | 34d | Information Systems | 8h |
| 92 | GRBAPI.PINT.04.030 | Develop Automated Scripts |  | 1d | 2020-01-28 | 2020-01-29 | 90SS | 35d | Information Systems | 8h |
| 93 | GRBAPI.PINT.04.040 | Establish External Test Data Sets |  | 1d | 2020-01-29 | 2020-01-30 | 90 | 0d | Information Systems | 8h |
| 94 | 4.5.3.5 | System Test Design and Development Complete | milestone | 0d | 2020-01-30 | 2020-01-30 | 93 | 0d |  |  |
| 95 | 4.5.4 | **System Test Execution** |  | 3d | 2020-01-30 | 2020-02-04 |  | 0d |  | 24h |
| 96 | GRBAPI.PINT.05.010 | Execute Tests and Log Results |  | 1d | 2020-01-30 | 2020-01-31 | 94 | 0d | Information Systems | 8h |
| 97 | GRBAPI.PINT.05.020 | Investigate Unexpected Results |  | 1d | 2020-01-31 | 2020-02-03 | 96 | 0d | Information Systems | 8h |
| 98 | GRBAPI.PINT.05.030 | Estimate, Prioritize, and Schedule Testing Changes |  | 1d | 2020-02-03 | 2020-02-04 | 97 | 0d | Information Systems | 8h |
| 99 | 4.5.4.4 | System Test Execution Complete | milestone | 0d | 2020-02-04 | 2020-02-04 | 98 | 0d |  |  |
| 100 | 4.5.5 | **Iteration Review** |  | 2d | 2020-02-04 | 2020-02-06 |  | 0d |  | 32h |
| 101 | GRBAPI.PINT.06.010 | Review System Test Results for Current Iteration |  | 1d | 2020-02-04 | 2020-02-05 | 99 | 0d | Information Systems; Business User (SME) | 16h |
| 102 | GRBAPI.PINT.06.020 | Confirm Scope of Future Iterations |  | 1d | 2020-02-05 | 2020-02-06 | 101 | 0d | Business User (SME); Information Systems | 16h |
| 103 | 4.5.5.3 | Iteration Review Complete | milestone | 0d | 2020-02-06 | 2020-02-06 | 102 | 0d |  |  |
| 104 | 4.5.6 | **Acceptance Testing** |  | 6d | 2020-02-06 | 2020-02-14 |  | 0d |  | 88h |
| 105 | GRBAPI.PINT.07.010 | Set Up Acceptance Test Environment |  | 1d | 2020-02-06 | 2020-02-07 | 103 | 0d | Information Systems | 8h |
| 106 | GRBAPI.PINT.07.020 | Create Acceptance Test Scripts |  | 1d | 2020-02-07 | 2020-02-10 | 105 | 0d | Information Systems; Business User (SME) | 16h |
| 107 | GRBAPI.PINT.07.030 | Execute Acceptance Tests and Log Results |  | 1d | 2020-02-10 | 2020-02-11 | 106 | 0d | Information Systems; Business User (SME) | 16h |
| 108 | GRBAPI.PINT.07.040 | Update System Based on Acceptance Test Results |  | 1d | 2020-02-11 | 2020-02-12 | 107 | 0d | Information Systems; Business User (SME) | 16h |
| 109 | GRBAPI.PINT.07.050 | Re-Execute Acceptance Tests and Log Results |  | 1d | 2020-02-12 | 2020-02-13 | 108 | 0d | Information Systems; Business User (SME) | 16h |
| 110 | GRBAPI.PINT.07.060 | Obtain Signoff of System |  | 1d | 2020-02-13 | 2020-02-14 | 109 | 0d | Information Systems; Business User (SME) | 16h |
| 111 | 4.5.6.7 | Acceptance Testing Complete | milestone | 0d | 2020-02-14 | 2020-02-14 | 110 | 23d |  |  |
| 112 | 4.5.7 | Package Implementation Complete | milestone | 0d | 2020-02-14 | 2020-02-14 | 110 | 0d |  |  |

| ID | WBS | Task | Type | Duration | Start | Finish | Predecessors | Total slack | Resources | Work |
| --- | --- | --- | --- | --- | --- | --- | --- | --- | --- | --- |
| 113 | 4.5.8 | **Finalize Integration Phase** |  | 4d | 2020-02-14 | 2020-02-20 |  | 0d |  | 56h |
| 114 | GRBAPI.PINT.GRSEA.010 | Develop Requirements Traceability Matrix |  | 1d | 2020-02-14 | 2020-02-17 | 112 | 0d | Business User (SME); Information Systems | 16h |
| 115 | GRBAPI.PINT.GRSEA.020 | Baseline Project/Deliverables |  | 1d | 2020-02-17 | 2020-02-18 | 114 | 0d | Business User (SME); Information Systems | 16h |
| 116 | GRBAPI.PINT.GRSEA.030 | Develop Schedule for Next Stage |  | 1d | 2020-02-18 | 2020-02-19 | 115 | 0d | Business User (SME); Information Systems | 16h |
| 117 | GRBAPI.PINT.GRSEA.040 | Review Project Status with Project Board |  | 1d | 2020-02-19 | 2020-02-20 | 116 | 0d | Business User (SME) | 8h |
| 118 | 4.5.8.5 | Finalize Integration Phase Complete | milestone | 0d | 2020-02-20 | 2020-02-20 | 117 | 0d |  |  |
| 119 | 4.6 | **Deploy** |  | 15d | 2020-02-20 | 2020-03-12 |  | 0d |  | 152h |
| 120 | 4.6.1 | **Education Development** |  | 4d | 2020-02-20 | 2020-02-26 |  | 0d |  | 56h |
| 121 | 4.6.1.1 | Set Up Training Environment |  | 1d | 2020-02-20 | 2020-02-21 | 118 | 0d | Information Systems | 8h |
| 122 | 4.6.1.2 | Create Application User Guide |  | 1d | 2020-02-21 | 2020-02-24 | 121 | 0d | Information Systems; Business User (SME) | 16h |
| 123 | 4.6.1.3 | Create Administrators Guide |  | 1d | 2020-02-24 | 2020-02-25 | 122 | 0d | Information Systems; Business User (SME) | 16h |
| 124 | 4.6.1.4 | Develop Training Materials |  | 1d | 2020-02-25 | 2020-02-26 | 123 | 0d | Information Systems; Business User (SME) | 16h |
| 125 | 4.6.1.5 | Education Development Complete | milestone | 0d | 2020-02-26 | 2020-02-26 | 124 | 0d |  |  |
| 126 | 4.6.2 | **Deployment Preparation** |  | 6d | 2020-02-26 | 2020-03-05 |  | 0d |  | 56h |
| 127 | 4.6.2.1 | Develop Background Scheduling Processes |  | 1d | 2020-02-26 | 2020-02-27 | 125 | 0d | Information Systems | 8h |
| 128 | 4.6.2.2 | Create Production Test Scripts |  | 1d | 2020-02-27 | 2020-02-28 | 127 | 0d | Information Systems | 8h |
| 129 | 4.6.2.3 | Review and Compile Technical Implementation Plan |  | 1d | 2020-02-28 | 2020-03-02 | 127, 128 | 0d | Information Systems | 8h |
| 130 | 4.6.2.4 | Establish Technical Environment |  | 1d | 2020-03-02 | 2020-03-03 | 129 | 0d | Information Systems | 8h |
| 131 | 4.6.2.5 | Conduct Deployment Briefings |  | 1d | 2020-03-03 | 2020-03-04 | 130 | 0d | Information Systems | 8h |
| 132 | 4.6.2.6 | Conduct Training |  | 1d | 2020-03-04 | 2020-03-05 | 131 | 9d | Business User (SME) | 8h |
| 133 | 4.6.2.7 | Complete Implementation Plan |  | 1d | 2020-03-04 | 2020-03-05 | 131 | 0d | Project Manager | 8h |
| 134 | 4.6.2.8 | Deployment Preparation Complete | milestone | 0d | 2020-03-05 | 2020-03-05 | 133 | 0d |  |  |
| 135 | 4.6.3 | **Installation and Handover** |  | 5d | 2020-03-05 | 2020-03-12 |  | 0d |  | 40h |
| 136 | 4.6.3.1 | Install Application Software |  | 1d | 2020-03-05 | 2020-03-06 | 134 | 0d | Information Systems | 8h |
| 137 | 4.6.3.2 | Convert Static and Acquire New Data |  | 1d | 2020-03-06 | 2020-03-09 | 136 | 0d | Information Systems | 8h |
| 138 | 4.6.3.3 | Convert Dynamic Data |  | 1d | 2020-03-06 | 2020-03-09 | 136 | 0d | Information Systems | 8h |
| 139 | 4.6.3.4 | Perform Production Tests |  | 1d | 2020-03-09 | 2020-03-10 | 137, 138 | 0d | Information Systems | 8h |
| 140 | 4.6.3.5 | Cut Over to New Application |  | 1d | 2020-03-10 | 2020-03-11 | 139 | 0d | Information Systems | 8h |
| 141 | 4.6.3.6 | Create Maintenance Guide |  | 1d | 2020-03-11 | 2020-03-12 | 140 | 0d |  |  |
| 142 | 4.6.3.7 | Installation and Handover Complete | milestone | 0d | 2020-03-12 | 2020-03-12 | 141 | 0d |  |  |

| ID | WBS | Task | Type | Duration | Start | Finish | Predecessors | Total slack | Resources | Work |
| --- | --- | --- | --- | --- | --- | --- | --- | --- | --- | --- |
| 143 | 5 | **Closure Phase** |  | 4d? | 2020-03-12 | 2020-03-18 |  | 0d |  | 32h |
| 144 | 5.1 | Perform Lessons Learned Meeting |  | 2d? | 2020-03-12 | 2020-03-16 | 142 | 0d | Project Manager | 16h |
| 145 | 5.2 | Close Project File |  | 2d? | 2020-03-16 | 2020-03-18 | 144 | 0d | Project Manager | 16h |
| 146 | 5.3 | Finalize Project Closure Report | milestone | 0d | 2020-03-18 | 2020-03-18 | 145 | 0d | Project Manager |  |
| 147 | 5.4 | Deployment Complete | milestone | 0d | 2020-03-18 | 2020-03-18 | 145 | 0d |  |  |
| 148 | 5.5 | Implementation Complete | milestone | 0d | 2020-03-18 | 2020-03-18 | 147 | 0d |  |  |
